# Subproyecto A3 : "Entrega de las Defensas Ribereñas del Río Lacramarca - Paquete 11 - R07"

Schedule from Primavera P6, 2023-05-01 to 2023-12-01, data date 2023-05-01.
Must finish by 2023-11-16

## Calendars

- SubProyecto A3: Mon-Sun 08:00-16:00.

## Resources

| Resource | Group |
| --- | --- |
| Operador Tractor | labor |
| Tractor D8 | equipment |
| Operador Excavadora | labor |
| Excavadora | equipment |
| Tractor D6 | equipment |
| Operador Rodillo | labor |
| Rodillo | equipment |
| Operador Motoniveladora | labor |
| Motoniveladora | equipment |
| Volquete | equipment |
| Operador Volquete | labor |

## Schedule

| ID | WBS | Activity | Duration | Start | Finish | Predecessors | Total float | Free float |
| --- | --- | --- | --- | --- | --- | --- | --- | --- |
|  | A | **HITOS** |  | 2023-05-01 | 2023-12-01 |  |  |  |
| H1 |  | KOM (Kick off Meeting) | 0d | 2023-05-01 | 2023-05-01 |  | -15d | 0d |
| H2 |  | INICIO DE PLAZO CONTRACTUAL - ACCESO AL SITIO (16 días calendario despues del KOM) | 0d | 2023-05-16 | 2023-05-16 | H1 FS+15d | -15d | 0d |
| H3 |  | INICIO DE EXCAVACION | 0d | 2023-05-21 | 2023-05-21 | H2 FS+5d | -15d | 0d |
| H4 |  | INICIO DE RELLENO DE DIQUE | 0d | 2023-06-11 | 2023-06-11 | 1.5.3.4 SS | 158d | 173d |
| H5 |  | FIN DE PLAZO DE CONTRACTUAL - CULMINACION DE OBRAS | 0d | 2023-12-01 | 2023-12-01 | 1.4.2, 1.5.1.5, 1.5.2.5, 1.5.3.5, 1.5.4.5, 1.5.5.5, 2.1.5.2, 2.1.6.2, 2.2.5.2, 2.3.3.1, 2.4.1.2.6, 2.4.2.2.7, 2.5.8, 3.6, 4.4.3, 4.4.6, 5.2, 2.4.1.1.3, 2.1.6.8, 4.4.7, 2.4.2.2.6, 1.2.11, 1.4.4, 3.2, 3.1, 6.1, 6.2 | -15d | 0d |
|  | 1 | **DEFENSAS RIBEREÑAS** |  | 2023-05-05 | 2023-11-30 |  |  |  |
|  | 1 | **OBRAS PRELIMINARES** |  | 2023-05-08 | 2023-11-10 |  |  |  |
| 1.1.2 |  | INSTALACIONES PROVISIONALES PARA LA OBRA | 15d | 2023-05-08 | 2023-05-22 | H1 FS+7d | 2d | 0d |
| 1.1.3 |  | MANTENIMIENTO DE TRÁNSITO Y SEGURIDAD VIAL | 175d | 2023-05-20 | 2023-11-10 | 1.2.1 FS-1d | 5d | 20d |
| 1.1.1 |  | CARTEL DE IDENTIFICACIÓN OBRA 4.80 x 3.60 m. | 2d | 2023-05-21 | 2023-05-22 | 1.2.1, H2 | 177d | 192d |
|  | 2 | **TRABAJOS PRELIMINARES** |  | 2023-05-05 | 2023-11-27 |  |  |  |
| 1.2.1 |  | MOVILIZACION DE EQUIPOS | 16d | 2023-05-05 | 2023-05-20 | H1 FS+4d | 5d | 0d |
| 1.2.2 |  | TOPOGRAFÍA Y GEOREFERENCIACIÓN | 190d | 2023-05-08 | 2023-11-13 | 1.1.2 SS | 2d | 0d |
| 1.2.11 |  | DESMOVILIZACION DE EQUIPOS | 45d | 2023-10-14 | 2023-11-27 | 3.5, 3.3, 3.4 | -12d | 3d |
|  | 3 | **MEJORAMIENTO DE VÍAS EXISTENTES** |  | 2023-05-15 | 2023-06-08 |  |  |  |
|  | 1 | **MOVIMIENTO DE TIERRAS** |  | 2023-05-15 | 2023-06-08 |  |  |  |
| 1.3.1.1 |  | ROCE Y LIMPIEZA DE MALEZA | 4d | 2023-05-15 | 2023-05-18 | 1.2.2 SS+7d | 160d | 0d |
| 1.3.1.2 |  | MEJORAMIENTO DE VIAS EXISTENTES | 22d | 2023-05-18 | 2023-06-08 | 1.3.1.1 SS+3d | 160d | 0d |
|  | 2 | **REPOSICIÓN DE ESTRUCTURAS** |  | 2023-05-22 | 2023-05-31 |  |  |  |
| 1.3.2.1 |  | DEMOLICIÓN DE ESTRUCTURAS EXISTENTES | 3d | 2023-05-22 | 2023-05-24 | 1.3.1.2 SS+4d | 162d | 0d |
| 1.3.2.2 |  | REPOSICIÓN DE PASE DE AGUA TUBO HDPE Ø=18" | 4d | 2023-05-25 | 2023-05-28 | 1.3.2.1 | 162d | 0d |
| 1.3.2.3 |  | REPOSICIÓN DE PASE DE AGUA TUBO HDPE Ø=36" | 4d | 2023-05-25 | 2023-05-28 | 1.3.2.2 SS | 162d | 0d |
| 1.3.2.4 |  | SUMINISTRO Y MONTAJE DE PANELES DE C°A° 1.6mx1.0mx0.20m EN PASE DE AGUA | 3d | 2023-05-29 | 2023-05-31 | 1.3.2.3 | 162d | 0d |
| 1.3.2.5 |  | SUMINISTRO Y MONTAJE DE PANELES DE C°A° 2.20mx1.0mx0.20m EN PASE DE AGUA | 3d | 2023-05-29 | 2023-05-31 | 1.3.2.4 SS | 162d | 0d |

| ID | WBS | Activity | Duration | Start | Finish | Predecessors | Total float | Free float | Resources |
| --- | --- | --- | --- | --- | --- | --- | --- | --- | --- |
|  | 3 | **CABEZAL DE ENTRADA Y SALIDA** |  | 2023-06-01 | 2023-06-06 |  |  |  |  |
| 1.3.3.2 |  | ENCOFRADO Y DESENCOFRADO RECTO | 5d | 2023-06-01 | 2023-06-05 | 1.3.2.5 | 162d | 0d |  |
| 1.3.3.1 |  | CONCRETOS | 3d | 2023-06-04 | 2023-06-06 | 1.3.3.2 FS-2d | 162d | 177d |  |
|  | 4 | **DESCOLMATACIÓN DE CAUCE y OBRAS AUXILIARES** |  | 2023-05-21 | 2023-11-30 |  |  |  |  |
| 1.4.1 |  | DESBROCE Y LIMPIEZA EN ZONA NO BOSCOSA | 43d | 2023-05-21 | 2023-07-02 | 1.2.1 | 129d | 0d | Operador Tractor [487.46 h]; Tractor D8 [487 h] |
| 1.4.2 |  | DESCOLMATACIÓN DE CAUCE NATURAL DEL RÍO LACRAMARCA | 43d | 2023-05-23 | 2023-07-04 | 1.4.1 SS+2d | 129d | 0d | Operador Tractor [1034 h]; Tractor D8 [1034 h] |
| 1.4.3 |  | CONFORMACIÓN DE DESVIO EN CAUCE DE RÍO | 33d | 2023-05-23 | 2023-06-24 | 1.4.2 SS | 129d | 144d | Operador Excavadora [457 h]; Excavadora [457 h] |
| 1.4.4 |  | RELLENO NO ESTRUCTURAL CON MATERIAL PROPIO | 33d | 2023-10-29 | 2023-11-30 | 1.4.3 SS+15d, 1.5.1.5, 1.5.2.5 FS-2d | -15d | 0d | Operador Tractor [459 h]; Tractor D6 [459 h] |
|  | 5 | **DIQUES DE TIERRA COMPACTADA CON ENROCADO** |  | 2023-05-21 | 2023-10-30 |  |  |  |  |
|  | 1 | **DIQUE DE TIERRA COMPACTADA A3-D-01** |  | 2023-07-29 | 2023-09-29 |  |  |  |  |
| 1.5.1.1 |  | EXCAVACIÓN EN TERRENO NATURAL CON EQUIPO | 7d | 2023-07-29 | 2023-08-04 | H3, 1.5.2.1, 1.5.2.2, 1.5.3.8 | 11d | 0d | Excavadora [62 h]; Tractor D6 [31 h]; Operador Excavadora [62 h]; Operador Tractor [31 h] |
| 1.5.1.2 |  | EXCAVACIÓN DE UÑA CON EQUIPO | 5d | 2023-08-05 | 2023-08-09 | 1.5.1.1 | 11d | 0d | Excavadora [37.2 h]; Operador Excavadora [37 h] |
| 1.5.1.3 |  | PERFILADO Y COMPACTACIÓN EN ZONA DE CORTE | 5d | 2023-08-10 | 2023-08-14 | 1.5.1.2 | 11d | 0d | Operador Rodillo [37 h]; Rodillo [37 h]; Operador Motoniveladora [40 h]; Motoniveladora [40 h] |
| 1.5.1.9 |  | PREPARACIÓN DE FUNDACIÓN DE CUERPO DE DIQUE | 3d | 2023-08-15 | 2023-08-17 | 1.5.1.3 | 11d | 0d | Rodillo [7 h]; Motoniveladora [7 h]; Operador Rodillo [7 h]; Operador Motoniveladora [7 h] |
| 1.5.1.4 |  | CONFORMACIÓN DE CUERPO DE DIQUE CON MATERIAL PROPIO | 5d | 2023-08-18 | 2023-08-22 | 1.5.1.9 | 11d | 0d | Operador Excavadora [39 h]; Excavadora [39 h]; Motoniveladora [38 h]; Operador Motoniveladora [38 h]; Operador Rodillo [38 h]; Rodillo [38 h] |
| 1.5.1.6 |  | GEOTEXTIL NO TEJIDO 400 G/M2, INC. COLOCACIÓN | 13d | 2023-08-23 | 2023-09-04 | 1.5.1.4 | 11d | 0d |  |
| 1.5.1.7 |  | COLOCACION Y ACOMODO DE ROCA EN UÑA DE DIQUE | 13d | 2023-08-27 | 2023-09-08 | 1.5.1.6 SS+4d | 11d | 0d | Operador Excavadora [526 h]; Excavadora [526 h] |
| 1.5.1.8 |  | COLOCACION Y ACOMODO DE ROCA EN TALUD DE DIQUE | 21d | 2023-09-03 | 2023-09-23 | 1.5.1.7 SS+7d | 11d | 0d | Excavadora [790 h]; Operador Excavadora [790 h] |
| 1.5.1.5 |  | CONFORMACIÓN DE CORONA DE DIQUE CON MATERIAL PROPIO | 6d | 2023-09-24 | 2023-09-29 | 1.5.1.8 | 14d | 29d | Motoniveladora [23 h]; Rodillo [23 h]; Excavadora [24 h]; Operador Motoniveladora [23 h]; Operador Rodillo [23 h]; Operador Excavadora [24 h] |
|  | 2 | **DIQUE DE TIERRA COMPACTADA A3-D-02** |  | 2023-05-21 | 2023-10-30 |  |  |  |  |
| 1.5.2.1 |  | EXCAVACIÓN EN TERRENO NATURAL CON EQUIPO | 26d | 2023-05-21 | 2023-06-15 | H3 | -15d | 0d | Operador Excavadora [533 h]; Excavadora [533 h]; Operador Tractor [266 h]; Tractor D6 [266 h] |
| 1.5.2.2 |  | EXCAVACIÓN DE UÑA CON EQUIPO | 14d | 2023-06-11 | 2023-06-24 | 1.5.2.1 FS-5d | -15d | 0d | Operador Excavadora [268 h]; Excavadora [268 h] |
| 1.5.2.3 |  | PERFILADO Y COMPACTACIÓN EN ZONA DE CORTE | 11d | 2023-06-21 | 2023-07-01 | 1.5.2.2 FS-4d | -15d | 0d | Operador Rodillo [105 h]; Operador Motoniveladora [233 h]; Rodillo [105 h]; Motoniveladora [233 h] |
| 1.5.2.9 |  | PREPARACIÓN DE FUNDACIÓN DE CUERPO DE DIQUE | 6d | 2023-07-02 | 2023-07-07 | 1.5.2.3 | -15d | 0d | Operador Motoniveladora [26 h]; Operador Rodillo [26 h]; Motoniveladora [26 h]; Rodillo [26 h] |
| 1.5.2.4 |  | CONFORMACIÓN DE CUERPO DE DIQUE CON MATERIAL PROPIO | 10d | 2023-07-05 | 2023-07-14 | 1.5.2.9 FS-3d | -15d | 0d | Operador Excavadora [164 h]; Operador Rodillo [160 h]; Excavadora [164 h]; Rodillo [160 h]; Operador Motoniveladora [160 h]; Motoniveladora [160 h] |
| 1.5.2.6 |  | GEOTEXTIL NO TEJIDO 400 G/M2, INC. COLOCACIÓN | 49d | 2023-07-13 | 2023-08-30 | 1.5.2.4 FS-2d | -15d | 0d |  |
| 1.5.2.7 |  | COLOCACION Y ACOMODO DE ROCA EN UÑA DE DIQUE | 51d | 2023-07-16 | 2023-09-04 | 1.5.2.6 SS+3d | -15d | 0d | Operador Excavadora [3779 h]; Excavadora [3779 h] |
| 1.5.2.8 |  | COLOCACION Y ACOMODO DE ROCA EN TALUD DE DIQUE | 73d | 2023-07-31 | 2023-10-11 | 1.5.2.7 SS+15d | -15d | 0d | Operador Excavadora [4525 h]; Excavadora [4525 h] |
| 1.5.2.5 |  | CONFORMACIÓN DE CORONA DE DIQUE CON MATERIAL PROPIO | 19d | 2023-10-12 | 2023-10-30 | 1.5.2.8 | -15d | 0d | Excavadora [119 h]; Rodillo [116 h]; Motoniveladora [116 h]; Operador Excavadora [119 h]; Operador Rodillo [116 h]; Operador Motoniveladora [116 h] |

| ID | WBS | Activity | Duration | Start | Finish | Predecessors | Total float | Free float | Resources |
| --- | --- | --- | --- | --- | --- | --- | --- | --- | --- |
|  | 3 | **DIQUE DE TIERRA COMPACTADA A3-I-01** |  | 2023-05-21 | 2023-08-01 |  |  |  |  |
| 1.5.3.1 |  | EXCAVACIÓN EN TERRENO NATURAL CON EQUIPO | 12d | 2023-05-21 | 2023-06-01 | H3 | -12d | 0d | Operador Excavadora [138 h]; Operador Tractor [69 h]; Excavadora [138 h]; Tractor D6 [69 h] |
| 1.5.3.2 |  | EXCAVACIÓN DE UÑA CON EQUIPO | 5d | 2023-05-30 | 2023-06-03 | 1.5.3.1 FS-3d | -12d | 0d | Operador Excavadora [37 h]; Excavadora [37 h] |
| 1.5.3.3 |  | PERFILADO Y COMPACTACIÓN EN ZONA DE CORTE | 4d | 2023-06-04 | 2023-06-07 | 1.5.3.2 | -12d | 0d | Rodillo [15 h]; Motoniveladora [32 h]; Operador Rodillo [15 h]; Operador Motoniveladora [32 h] |
| 1.5.3.9 |  | PREPARACIÓN DE FUNDACIÓN DE CUERPO DE DIQUE | 4d | 2023-06-08 | 2023-06-11 | 1.5.3.3 | -12d | 0d | Operador Motoniveladora [9 h]; Operador Rodillo [9 h]; Motoniveladora [9 h]; Rodillo [9 h] |
| 1.5.3.4 |  | CONFORMACIÓN DE CUERPO DE DIQUE CON MATERIAL PROPIO | 7d | 2023-06-11 | 2023-06-17 | 1.5.3.9 FS-1d | -12d | 0d | Operador Excavadora [66 h]; Operador Rodillo [64 h]; Operador Motoniveladora [64 h]; Motoniveladora [64 h]; Excavadora [66 h]; Rodillo [64 h] |
| 1.5.3.6 |  | GEOTEXTIL NO TEJIDO 400 G/M2, INC. COLOCACIÓN | 8d | 2023-06-18 | 2023-06-25 | 1.5.3.4 | -12d | 0d |  |
| 1.5.3.7 |  | COLOCACION Y ACOMODO DE ROCA EN UÑA DE DIQUE | 12d | 2023-06-26 | 2023-07-07 | 1.5.3.6 | -12d | 0d | Operador Excavadora [515 h]; Excavadora [515 h] |
| 1.5.3.8 |  | COLOCACION Y ACOMODO DE ROCA EN TALUD DE DIQUE | 21d | 2023-07-08 | 2023-07-28 | 1.5.3.7, 1.5.3.7 FF | 11d | 0d | Operador Excavadora [775 h]; Excavadora [775 h] |
| 1.5.3.5 |  | CONFORMACIÓN DE CORONA DE DIQUE CON MATERIAL PROPIO | 4d | 2023-07-29 | 2023-08-01 | 1.5.3.8 | 12d | 0d | Rodillo [23 h]; Motoniveladora [23 h]; Excavadora [23 h]; Operador Excavadora [23 h]; Operador Rodillo [23 h]; Operador Motoniveladora [23 h] |
|  | 4 | **DIQUE DE TIERRA COMPACTADA A3-I-02** |  | 2023-05-21 | 2023-08-23 |  |  |  |  |
| 1.5.4.1 |  | EXCAVACIÓN EN TERRENO NATURAL CON EQUIPO | 27d | 2023-05-21 | 2023-06-16 | H3 | -11d | 0d | Excavadora [188 h]; Tractor D6 [94 h]; Operador Excavadora [188 h]; Operador Tractor [94 h] |
| 1.5.4.2 |  | EXCAVACIÓN DE UÑA CON EQUIPO | 9d | 2023-06-14 | 2023-06-22 | 1.5.4.1 FS-3d | -11d | 0d | Operador Excavadora [50 h]; Excavadora [50 h] |
| 1.5.4.3 |  | PERFILADO Y COMPACTACIÓN EN ZONA DE CORTE | 7d | 2023-06-23 | 2023-06-29 | 1.5.4.2 | -11d | 0d | Operador Rodillo [19 h]; Operador Motoniveladora [40 h]; Rodillo [19 h]; Motoniveladora [40 h] |
| 1.5.4.9 |  | PREPARACIÓN DE FUNDACIÓN DE CUERPO DE DIQUE | 6d | 2023-06-30 | 2023-07-05 | 1.5.4.3 | -11d | 0d | Operador Rodillo [5 h]; Operador Motoniveladora [5 h]; Rodillo [5 h]; Motoniveladora [5 h] |
| 1.5.4.4 |  | CONFORMACIÓN DE CUERPO DE DIQUE CON MATERIAL PROPIO | 4d | 2023-07-06 | 2023-07-09 | 1.5.4.9 | -11d | 0d | Excavadora [14 h]; Operador Excavadora [14 h]; Rodillo [14 h]; Operador Rodillo [14 h]; Motoniveladora [14 h]; Operador Motoniveladora [14 h] |
| 1.5.4.6 |  | GEOTEXTIL NO TEJIDO 400 G/M2, INC. COLOCACIÓN | 12d | 2023-07-10 | 2023-07-21 | 1.5.4.4 | -11d | 0d |  |
| 1.5.4.7 |  | COLOCACION Y ACOMODO DE ROCA EN UÑA DE DIQUE | 30d | 2023-07-13 | 2023-08-11 | 1.5.4.6 SS+3d | -11d | 0d | Operador Excavadora [701 h]; Excavadora [701 h] |
| 1.5.4.8 |  | COLOCACION Y ACOMODO DE ROCA EN TALUD DE DIQUE | 23d | 2023-07-28 | 2023-08-19 | 1.5.4.7 SS+15d | -11d | 0d | Operador Excavadora [868 h]; Excavadora [868 h] |
| 1.5.4.5 |  | CONFORMACIÓN DE CORONA DE DIQUE CON MATERIAL PROPIO | 6d | 2023-08-18 | 2023-08-23 | 1.5.4.8 FS-2d | 84d | 99d | Excavadora [28 h]; Operador Excavadora [28 h]; Rodillo [27 h]; Operador Rodillo [27 h]; Motoniveladora [27 h]; Operador Motoniveladora [27 h] |
|  | 5 | **DIQUE DE TIERRA COMPACTADA A3-I-03** |  | 2023-05-21 | 2023-10-25 |  |  |  |  |
| 1.5.5.1 |  | EXCAVACIÓN EN TERRENO NATURAL CON EQUIPO | 25d | 2023-05-21 | 2023-06-14 | H3 | 21d | 0d | Operador Excavadora [346 h]; Excavadora [346 h] |
| 1.5.5.2 |  | EXCAVACIÓN DE UÑA CON EQUIPO | 17d | 2023-06-13 | 2023-06-29 | 1.5.5.1 FS-2d | 21d | 0d | Operador Excavadora [221 h]; Excavadora [221 h] |
| 1.5.5.3 |  | PERFILADO Y COMPACTACIÓN EN ZONA DE CORTE | 13d | 2023-06-28 | 2023-07-10 | 1.5.5.2 FS-2d | 21d | 0d | Operador Motoniveladora [181 h]; Operador Rodillo [85 h]; Rodillo [85 h]; Motoniveladora [181 h] |
| 1.5.5.9 |  | PREPARACIÓN DE FUNDACIÓN DE CUERPO DE DIQUE | 6d | 2023-07-11 | 2023-07-16 | 1.5.5.3 | 21d | 0d | Operador Rodillo [25 h]; Operador Motoniveladora [25 h]; Motoniveladora [25 h]; Rodillo [25 h] |
| 1.5.5.4 |  | CONFORMACIÓN DE CUERPO DE DIQUE CON MATERIAL PROPIO | 11d | 2023-07-15 | 2023-07-25 | 1.5.5.9 FS-2d | 21d | 0d | Operador Excavadora [133 h]; Operador Rodillo [130 h]; Operador Motoniveladora [130 h]; Rodillo [130 h]; Motoniveladora [130 h]; Excavadora [133 h] |
| 1.5.5.6 |  | GEOTEXTIL NO TEJIDO 400 G/M2, INC. COLOCACIÓN | 40d | 2023-07-26 | 2023-09-03 | 1.5.5.4 | 21d | 0d |  |
| 1.5.5.7 |  | COLOCACION Y ACOMODO DE ROCA EN UÑA DE DIQUE | 43d | 2023-07-29 | 2023-09-09 | 1.5.5.6 SS+3d | 21d | 0d | Operador Excavadora [3115 h]; Excavadora [3115 h] |
| 1.5.5.8 |  | COLOCACION Y ACOMODO DE ROCA EN TALUD DE DIQUE | 61d | 2023-08-13 | 2023-10-12 | 1.5.5.7 SS+15d | 21d | 0d | Operador Excavadora [3762 h]; Excavadora [3762 h] |
| 1.5.5.5 |  | CONFORMACIÓN DE CORONA DE DIQUE CON MATERIAL PROPIO | 16d | 2023-10-10 | 2023-10-25 | 1.5.5.8 FS-3d | 21d | 36d | Operador Excavadora [97 h]; Operador Rodillo [95 h]; Operador Motoniveladora [95 h]; Excavadora [97 h]; Rodillo [95 h]; Motoniveladora [95 h] |

| ID | WBS | Activity | Duration | Start | Finish | Predecessors | Total float | Free float | Resources |
| --- | --- | --- | --- | --- | --- | --- | --- | --- | --- |
|  | 6 | **RAMPAS** |  | 2023-09-23 | 2023-10-01 |  |  |  |  |
| 1.6.1 |  | EXCAVACIÓN EN TERRENO NATURAL CON EQUIPO | 3d | 2023-09-23 | 2023-09-25 | 1.5.5.8 FS-20d | 45d | 0d | Excavadora [6 h]; Operador Excavadora [6 h]; Tractor D6 [6 h]; Operador Tractor [6 h] |
| 1.6.2 |  | CONFORMACIÓN DE CUERPO DE RAMPA CON MATERIAL PROPIO | 3d | 2023-09-26 | 2023-09-28 | 1.6.1 | 45d | 0d | Excavadora [7 h]; Operador Excavadora [7 h]; Rodillo [7 h]; Operador Rodillo [7 h]; Motoniveladora [7 h]; Operador Motoniveladora [7 h] |
| 1.6.3 |  | CONFORMACIÓN DE CORONACIÓN DE RAMPA | 3d | 2023-09-29 | 2023-10-01 | 1.6.2 | 45d | 60d | Excavadora [5 h]; Operador Excavadora [5 h]; Motoniveladora [5 h]; Operador Motoniveladora [5 h]; Operador Rodillo [5 h]; Rodillo [5 h] |
|  | 2 | **OBRAS DE ARTE** |  | 2023-07-29 | 2023-11-29 |  |  |  |  |
|  | 1 | **CAPTACIÓN A3-CP-23-95** |  | 2023-07-31 | 2023-11-29 |  |  |  |  |
|  | 1 | **MOVIMIENTO DE TIERRAS** |  | 2023-07-31 | 2023-09-08 |  |  |  |  |
| 2.1.1.1 |  | EXCAVACIÓN ESTRUCTURAL PARA OBRAS DE ARTE | 8d | 2023-07-31 | 2023-08-07 | 1.5.2.8 SS | -14d | 0d |  |
| 2.1.1.2 |  | RELLENO ESTRUCTURAL PARA OBRAS DE ARTE, CON MATERIAL PROPIO | 5d | 2023-09-04 | 2023-09-08 | 2.1.2.2 | 68d | 83d |  |
|  | 2 | **OBRAS DE CONCRETO** |  | 2023-08-08 | 2023-09-03 |  |  |  |  |
| 2.1.2.3 |  | CONCRETO CICLÓPEO f'c=280 kg/cm2 + 30% P.G. | 3d | 2023-08-08 | 2023-08-10 | 2.1.1.1 | -14d | 0d |  |
| 2.1.2.1 |  | CONCRETO f'c=100 kg/cm2 | 3d | 2023-08-11 | 2023-08-13 | 2.1.2.3 | -14d | 0d |  |
| 2.1.2.5 |  | ACERO DE REFUERZO fy=4200 kg/cm2 | 11d | 2023-08-14 | 2023-08-24 | 2.1.2.1 | -14d | 0d |  |
| 2.1.2.4 |  | ENCOFRADO Y DESENCOFRADO RECTO | 7d | 2023-08-23 | 2023-08-29 | 2.1.2.5 FS-2d | -14d | 0d |  |
| 2.1.2.2 |  | CONCRETO f'c=280 kg/cm2 | 5d | 2023-08-30 | 2023-09-03 | 2.1.2.4 | -14d | 0d |  |
|  | 3 | **ESTRUCTURAS METALICAS** |  | 2023-09-04 | 2023-09-18 |  |  |  |  |
| 2.1.3.1 |  | COMPUERTA METALICA PLANA DESLIZANTE DE 1.0x1.0m | 3d | 2023-09-04 | 2023-09-06 | 2.1.2.2 | 58d | 0d |  |
| 2.1.3.2 |  | REJILLA DE 1.00x1.00m CON VARILLA DE 1/2" CADA 6,25cm | 3d | 2023-09-07 | 2023-09-09 | 2.1.3.1 | 58d | 0d |  |
| 2.1.3.3 |  | BARANDA DE FIERRO GALVANIZADO 1 1/2" | 3d | 2023-09-10 | 2023-09-12 | 2.1.3.2 | 58d | 0d |  |
| 2.1.3.4 |  | ESCALERA TIPO GATO | 3d | 2023-09-13 | 2023-09-15 | 2.1.3.3 | 58d | 0d |  |
| 2.1.3.5 |  | TAPA METALICA CIRCULAR DN600 MM | 3d | 2023-09-16 | 2023-09-18 | 2.1.3.4 | 58d | 73d |  |
|  | 4 | **TUBERIAS** |  | 2023-09-04 | 2023-10-30 |  |  |  |  |
| 2.1.4.1 |  | EXCAVACIÓN ESTRUCTURAL PARA OBRAS DE ARTE (Buzones) | 5d | 2023-09-04 | 2023-09-08 | 2.1.2.2 | -14d | 0d |  |
| 2.1.4.6 |  | CONCRETO f'c=100 kg/cm2 (Buzones) | 3d | 2023-09-09 | 2023-09-11 | 2.1.4.1 | 16d | 0d |  |
| 2.1.4.10 |  | ACERO DE REFUERZO fy=4200 kg/cm2 (Buzones) | 5d | 2023-09-12 | 2023-09-16 | 2.1.4.6 | 16d | 0d |  |
| 2.1.4.9 |  | ENCOFRADO Y DESENCOFRADO CURVO | 5d | 2023-09-15 | 2023-09-19 | 2.1.4.10 FS-2d | 16d | 0d |  |
| 2.1.4.8 |  | ENCOFRADO Y DESENCOFRADO RECTO | 4d | 2023-09-20 | 2023-09-23 | 2.1.4.9 | 16d | 0d |  |
| 2.1.4.7 |  | CONCRETO f'c=280 kg/cm2 (Buzones) | 3d | 2023-09-24 | 2023-09-26 | 2.1.4.8 | 16d | 0d |  |
| 2.1.4.2 |  | EXCAVACIÓN DE ZANJA | 13d | 2023-09-27 | 2023-10-09 | 2.1.4.7, 2.1.2.2 | 16d | 0d |  |
| 2.1.4.3 |  | RELLENO ESTRUCTURAL PARA OBRAS DE ARTE CON MATERIAL PROPIO (Buzones) | 3d | 2023-09-27 | 2023-09-29 | 2.1.4.7 | 47d | 62d |  |
| 2.1.4.4 |  | CAMA DE ARENA | 6d | 2023-10-10 | 2023-10-15 | 2.1.4.2 | 16d | 0d |  |
| 2.1.4.11 |  | SUMINISTRO E INSTALACIÓN DE TUBERÍA GRP DN600 mm SN2500 | 7d | 2023-10-16 | 2023-10-22 | 2.1.4.4 | 16d | 0d |  |
| 2.1.4.5 |  | RELLENO COMÚN PARA ZANJAS | 8d | 2023-10-23 | 2023-10-30 | 2.1.4.11 | 16d | 31d |  |

| ID | WBS | Activity | Duration | Start | Finish | Predecessors | Total float | Free float |
| --- | --- | --- | --- | --- | --- | --- | --- | --- |
|  | 5 | **CANAL** |  | 2023-09-09 | 2023-11-12 |  |  |  |
| 2.1.5.1 |  | EXCAVACIÓN ESTRUCTURAL PARA OBRAS DE ARTE | 8d | 2023-09-09 | 2023-09-16 | 2.1.1.1 FS+5d, 2.1.4.1 | -14d | 0d |
| 2.1.5.3 |  | COLOCACIÓN DE CONCRETO f'c=100 kg/cm2 | 4d | 2023-09-17 | 2023-09-20 | 2.1.5.1 | -14d | 0d |
| 2.1.5.6 |  | ACERO DE REFUERZO fy=4200 kg/cm2 | 13d | 2023-09-21 | 2023-10-03 | 2.1.5.3 | -14d | 0d |
| 2.1.5.5 |  | ENCOFRADO Y DESENCOFRADO RECTO | 30d | 2023-09-26 | 2023-10-25 | 2.1.5.6 SS+5d | -14d | 0d |
| 2.1.5.7 |  | JUNTA WATER STOP SIN BULBO 150 mm | 4d | 2023-10-26 | 2023-10-29 | 2.1.5.5 | -14d | 0d |
| 2.1.5.4 |  | COLOCACIÓN DE CONCRETO f'c=280 kg/cm2 | 5d | 2023-10-30 | 2023-11-03 | 2.1.5.7 | -14d | 0d |
| 2.1.5.2 |  | RELLENO ESTRUCTURAL PARA CANALES, CON MATERIAL PROPIO | 9d | 2023-11-04 | 2023-11-12 | 2.1.5.4 | 3d | 18d |
|  | 6 | **OBRAS DE DESCARGA** |  | 2023-11-04 | 2023-11-29 |  |  |  |
| 2.1.6.1 |  | EXCAVACIÓN ESTRUCTURAL PARA OBRAS DE ARTE | 3d | 2023-11-04 | 2023-11-06 | 2.1.5.4 | -14d | 0d |
| 2.1.6.3 |  | CONCRETO f'c=100 kg/cm2 | 3d | 2023-11-07 | 2023-11-09 | 2.1.6.1 | -14d | 0d |
| 2.1.6.6 |  | ACERO DE REFUERZO fy=4200 kg/cm2 | 3d | 2023-11-10 | 2023-11-12 | 2.1.6.3 | -14d | 0d |
| 2.1.6.5 |  | ENCOFRADO Y DESENCOFRADO RECTO | 5d | 2023-11-13 | 2023-11-17 | 2.1.6.6 | -14d | 0d |
| 2.1.6.7 |  | JUNTA WATER STOP SIN BULBO 150 mm | 4d | 2023-11-15 | 2023-11-18 | 2.1.6.5 SS+2d | -14d | 0d |
| 2.1.6.4 |  | CONCRETO f'c=280 kg/cm2 | 3d | 2023-11-19 | 2023-11-21 | 2.1.6.7 | -14d | 0d |
| 2.1.6.2 |  | RELLENO ESTRUCTURAL PARA OBRAS DE ARTE CON MATERIAL PROPIO | 3d | 2023-11-22 | 2023-11-24 | 2.1.6.4 | -14d | 0d |
| 2.1.6.8 |  | COMPUERTA METALICA PLANA DESLIZANTE | 5d | 2023-11-25 | 2023-11-29 | 2.1.6.2 | -14d | 1d |
|  | 2 | **CAPTACIÓN A3-CP-21-05** |  | 2023-07-29 | 2023-10-13 |  |  |  |
|  | 1 | **MOVIMIENTO DE TIERRAS** |  | 2023-07-29 | 2023-09-06 |  |  |  |
| 2.2.1.1 |  | EXCAVACIÓN ESTRUCTURAL PARA OBRAS DE ARTE | 6d | 2023-07-29 | 2023-08-03 | 1.5.3.8 | 33d | 0d |
| 2.2.1.2 |  | RELLENO ESTRUCTURAL PARA OBRAS DE ARTE, CON MATERIAL PROPIO | 5d | 2023-09-02 | 2023-09-06 | 2.2.2.2 | 70d | 85d |
|  | 2 | **OBRAS DE CONCRETO** |  | 2023-08-04 | 2023-09-01 |  |  |  |
| 2.2.2.3 |  | CONCRETO CICLÓPEO f'c=280 kg/cm2 + 30% P.G. | 3d | 2023-08-04 | 2023-08-06 | 2.2.1.1 | 57d | 0d |
| 2.2.2.1 |  | CONCRETO f'c=100 kg/cm2 | 3d | 2023-08-07 | 2023-08-09 | 2.2.2.3 | 57d | 0d |
| 2.2.2.5 |  | ACERO DE REFUERZO fy=4200 kg/cm2 | 11d | 2023-08-10 | 2023-08-20 | 2.2.2.1 | 57d | 0d |
| 2.2.2.4 |  | ENCOFRADO Y DESENCOFRADO RECTO | 12d | 2023-08-14 | 2023-08-25 | 2.2.2.5 SS+4d | 57d | 0d |
| 2.2.2.2 |  | CONCRETO f'c=280 kg/cm2 | 7d | 2023-08-26 | 2023-09-01 | 2.2.2.4 | 57d | 0d |

| ID | WBS | Activity | Duration | Start | Finish | Predecessors | Total float | Free float |
| --- | --- | --- | --- | --- | --- | --- | --- | --- |
|  | 3 | **ESTRUCTURAS METALICAS** |  | 2023-09-02 | 2023-09-19 |  |  |  |
| 2.2.3.1 |  | COMPUERTA METALICA PLANA DESLIZANTE DE 1.0x1.0m | 3d | 2023-09-02 | 2023-09-04 | 2.2.2.2 | 57d | 0d |
| 2.2.3.2 |  | REJILLA DE 1.00x1.00m CON VARILLA DE 1/2 CADA 6,25cm | 3d | 2023-09-05 | 2023-09-07 | 2.2.3.1 | 57d | 0d |
| 2.2.3.3 |  | BARANDA DE FIERRO GALVANIZADO 1 1/2" | 6d | 2023-09-08 | 2023-09-13 | 2.2.3.2 | 57d | 0d |
| 2.2.3.4 |  | ESCALERA TIPO GATO | 3d | 2023-09-14 | 2023-09-16 | 2.2.3.3 | 57d | 0d |
| 2.2.3.5 |  | TAPA METALICA CIRCULAR DN600 MM | 3d | 2023-09-17 | 2023-09-19 | 2.2.3.4 | 57d | 72d |
|  | 4 | **TUBERIAS** |  | 2023-08-04 | 2023-09-06 |  |  |  |
| 2.2.4.1 |  | EXCAVACIÓN ESTRUCTURAL PARA OBRAS DE ARTE (Buzones) | 3d | 2023-08-04 | 2023-08-06 | 2.2.1.1 | 33d | 0d |
| 2.2.4.7 |  | CONCRETO f'c=100 kg/cm2 (Buzones) | 3d | 2023-08-07 | 2023-08-09 | 2.2.4.1 | 33d | 0d |
| 2.2.4.11 |  | ACERO DE REFUERZO fy=4200 kg/cm2 | 3d | 2023-08-10 | 2023-08-12 | 2.2.4.7 | 33d | 0d |
| 2.2.4.10 |  | ENCOFRADO Y DESENCOFRADO CURVO | 4d | 2023-08-13 | 2023-08-16 | 2.2.4.11 | 33d | 0d |
| 2.2.4.9 |  | ENCOFRADO Y DESENCOFRADO RECTO | 3d | 2023-08-17 | 2023-08-19 | 2.2.4.10 | 33d | 0d |
| 2.2.4.8 |  | CONCRETO f'c=280 kg/cm2 (Buzones) | 3d | 2023-08-20 | 2023-08-22 | 2.2.4.9 | 33d | 0d |
| 2.2.4.2 |  | EXCAVACIÓN DE ZANJA | 3d | 2023-08-23 | 2023-08-25 | 2.2.4.8, 2.2.1.1 | 33d | 0d |
| 2.2.4.3 |  | RELLENO ESTRUCTURAL PARA OBRAS DE ARTE CON MATERIAL PROPIO | 3d | 2023-08-23 | 2023-08-25 | 2.2.4.8 | 82d | 97d |
| 2.2.4.4 |  | CAMA DE ARENA | 3d | 2023-08-26 | 2023-08-28 | 2.2.4.2 | 33d | 0d |
| 2.2.4.12 |  | SUMINISTRO E INSTALACIÓN DE TUBERÍA GRP DN600 mm SN2500 | 3d | 2023-08-29 | 2023-08-31 | 2.2.4.4 | 33d | 0d |
| 2.2.4.6 |  | RELLENO COMÚN PARA ZANJAS | 3d | 2023-09-01 | 2023-09-03 | 2.2.4.12 | 70d | 0d |
| 2.2.4.5 |  | RELLENO SELECCIONADO PARA ZANJAS CON MATERIAL PROPIO | 3d | 2023-09-04 | 2023-09-06 | 2.2.4.6 | 70d | 85d |
|  | 5 | **CANALES** |  | 2023-09-01 | 2023-10-13 |  |  |  |
| 2.2.5.1 |  | EXCAVACIÓN ESTRUCTURAL PARA OBRAS DE ARTE | 7d | 2023-09-01 | 2023-09-07 | 2.2.4.12 | 33d | 0d |
| 2.2.5.3 |  | COLOCACIÓN DE CONCRETO f'c=100 kg/cm2 | 3d | 2023-09-08 | 2023-09-10 | 2.2.5.1 | 33d | 0d |
| 2.2.5.6 |  | ACERO DE REFUERZO fy=4200 kg/cm2 | 6d | 2023-09-11 | 2023-09-16 | 2.2.5.3 | 33d | 0d |
| 2.2.5.5 |  | ENCOFRADO Y DESENCOFRADO | 16d | 2023-09-15 | 2023-09-30 | 2.2.5.6 SS+4d | 33d | 0d |
| 2.2.5.7 |  | JUNTA WATER STOP SIN BULBO 150 mm | 3d | 2023-10-01 | 2023-10-03 | 2.2.5.5 | 33d | 0d |
| 2.2.5.4 |  | COLOCACIÓN DE CONCRETO f'c=280 kg/cm2 | 4d | 2023-10-04 | 2023-10-07 | 2.2.5.7 | 33d | 0d |
| 2.2.5.2 |  | RELLENO ESTRUCTURAL PARA CANALES, CON MATERIAL PROPIO | 6d | 2023-10-08 | 2023-10-13 | 2.2.5.4 | 33d | 48d |

| ID | WBS | Activity | Duration | Start | Finish | Predecessors | Total float | Free float |
| --- | --- | --- | --- | --- | --- | --- | --- | --- |
|  | 3 | **RETORNO A3-OA-RE-D-21-55** |  | 2023-09-24 | 2023-11-04 |  |  |  |
|  | 1 | **MOVIMIENTO DE TIERRAS** |  | 2023-09-24 | 2023-10-30 |  |  |  |
| 2.3.1.1 |  | EXCAVACIÓN ESTRUCTURAL PARA OBRAS DE ARTE | 3d | 2023-09-24 | 2023-09-26 | 1.5.1.8 | 11d | 0d |
| 2.3.1.2 |  | RELLENO ESTRUCTURAL PARA OBRAS DE ARTE, CON MATERIAL PROPIO | 3d | 2023-10-28 | 2023-10-30 | 2.3.2.2 | 11d | 0d |
|  | 2 | **OBRAS DE CONCRETO** |  | 2023-09-27 | 2023-10-27 |  |  |  |
| 2.3.2.3 |  | CONCRETO CICLÓPEO f'c=280 kg/cm2 + 30% P.G. | 4d | 2023-09-27 | 2023-09-30 | 2.3.1.1 | 11d | 0d |
| 2.3.2.1 |  | CONCRETO f'c=100 kg/cm2 | 3d | 2023-10-01 | 2023-10-03 | 2.3.2.3 | 11d | 0d |
| 2.3.2.5 |  | ACERO DE REFUERZO fy=4200 kg/cm2 | 13d | 2023-10-04 | 2023-10-16 | 2.3.2.1 | 11d | 0d |
| 2.3.2.4 |  | ENCOFRADO Y DESENCOFRADO | 6d | 2023-10-14 | 2023-10-19 | 2.3.2.5 FS-3d | 11d | 0d |
| 2.3.2.6 |  | JUNTA WATER STOP SIN BULBO 150 mm | 4d | 2023-10-20 | 2023-10-23 | 2.3.2.4 | 11d | 0d |
| 2.3.2.2 |  | CONCRETO f'c=280 kg/cm2 | 4d | 2023-10-24 | 2023-10-27 | 2.3.2.6 | 11d | 0d |
|  | 3 | **ESTRUCTURAS METALICAS** |  | 2023-10-31 | 2023-11-04 |  |  |  |
| 2.3.3.1 |  | COMPUERTA METALICA PLANA DESLIZANTE DE 1.0x1.6 m | 3d | 2023-10-31 | 2023-11-02 | 2.3.1.2 | 11d | 0d |
| 2.3.3.2 |  | BARANDA DE FIERRO GALVANIZADO 1 1/2" | 2d | 2023-11-03 | 2023-11-04 | 2.3.3.1 | 11d | 26d |
|  | 4 | **REPOSICIÓN DE CANALES** |  | 2023-08-02 | 2023-11-26 |  |  |  |
|  | 1 | **REPOSICIÓN DE CANAL 1** |  | 2023-08-20 | 2023-11-26 |  |  |  |
|  | 1 | **MOVIMIENTO DE TIERRAS** |  | 2023-08-20 | 2023-11-26 |  |  |  |
| 2.4.1.1.1 |  | DEMOLICIÓN DE ESTRUCTURAS EXISTENTES | 6d | 2023-08-20 | 2023-08-25 | 1.5.4.8 | -11d | 0d |
| 2.4.1.1.2 |  | EXCAVACIÓN EN TERRENO NATURAL CON EQUIPO | 7d | 2023-08-26 | 2023-09-01 | 2.4.1.1.1 | -11d | 0d |
| 2.4.1.1.3 |  | RELLENO ESTRUCTURAL PARA OBRAS DE ARTE CON MATERIAL PROPIO | 9d | 2023-11-18 | 2023-11-26 | 2.4.1.2.4 FS-3d | -11d | 4d |
|  | 2 | **OBRAS DE CONCRETO** |  | 2023-09-02 | 2023-11-23 |  |  |  |
| 2.4.1.2.3 |  | CONCRETO f'c=100 kg/cm2 | 7d | 2023-09-02 | 2023-09-08 | 2.4.1.1.2 | -11d | 0d |
| 2.4.1.2.2 |  | ACERO DE REFUERZO fy=4200 kg/cm2 | 25d | 2023-09-09 | 2023-10-03 | 2.4.1.2.3 | -11d | 0d |
| 2.4.1.2.1 |  | ENCOFRADO Y DESENCOFRADO RECTO | 47d | 2023-09-17 | 2023-11-02 | 2.4.1.2.2 SS+8d | -11d | 0d |
| 2.4.1.2.5 |  | JUNTA WATER STOP 6" | 8d | 2023-11-03 | 2023-11-10 | 2.4.1.2.1 | -11d | 0d |
| 2.4.1.2.4 |  | CONCRETO f'c=280 kg/cm2 | 10d | 2023-11-11 | 2023-11-20 | 2.4.1.2.5 | -11d | 0d |
| 2.4.1.2.6 |  | MAMPOSTERIA DE PIEDRA, e=20cm, ACABADO CARA VISTA | 3d | 2023-11-21 | 2023-11-23 | 2.4.1.2.4 | -8d | 7d |

| ID | WBS | Activity | Duration | Start | Finish | Predecessors | Total float | Free float |
| --- | --- | --- | --- | --- | --- | --- | --- | --- |
|  | 2 | **REPOSICIÓN DE CANAL 3** |  | 2023-08-02 | 2023-09-27 |  |  |  |
|  | 1 | **MOVIMIENTO DE TIERRAS** |  | 2023-08-02 | 2023-09-17 |  |  |  |
| 2.4.2.1.1 |  | DEMOLICIÓN DE ESTRUCTURAS EXISTENTES | 7d | 2023-08-02 | 2023-08-08 | 1.5.3.5 | 49d | 0d |
| 2.4.2.1.2 |  | EXCAVACIÓN EN TERRENO NATURAL CON EQUIPO | 3d | 2023-08-09 | 2023-08-11 | 2.4.2.1.1 | 49d | 0d |
| 2.4.2.1.3 |  | RELLENO ESTRUCTURAL PARA OBRAS DE ARTE CON MATERIAL PROPIO | 3d | 2023-09-15 | 2023-09-17 | 2.4.2.2.5 | 59d | 74d |
|  | 2 | **OBRAS DE CONCRETO** |  | 2023-08-12 | 2023-09-27 |  |  |  |
| 2.4.2.2.4 |  | CONCRETO f'c=100 kg/cm2 | 4d | 2023-08-12 | 2023-08-15 | 2.4.2.1.2 | 49d | 0d |
| 2.4.2.2.3 |  | MALLA ELECTROSOLDADA DE DN6mm EN CUADRICULA 15x15 cm | 9d | 2023-08-16 | 2023-08-24 | 2.4.2.2.4 | 49d | 0d |
| 2.4.2.2.1 |  | ENCOFRADO Y DESENCOFRADO PARA REVESTIMIENTO DE CANALES (CERCHAS) | 4d | 2023-08-24 | 2023-08-27 | 2.4.2.2.3 FS-1d | 49d | 0d |
| 2.4.2.2.2 |  | ENCOFRADO Y DESENCOFRADO RECTO | 13d | 2023-08-28 | 2023-09-09 | 2.4.2.2.1 | 49d | 0d |
| 2.4.2.2.5 |  | CONCRETO f'c=280 kg/cm2 | 5d | 2023-09-10 | 2023-09-14 | 2.4.2.2.2 | 49d | 0d |
| 2.4.2.2.6 |  | SELLO DE JUNTA CONSTRUCCIÓN CON MATERIAL ELASTOMÉRICO | 13d | 2023-09-15 | 2023-09-27 | 2.4.2.2.5 | 49d | 64d |
| 2.4.2.2.7 |  | MAMPOSTERIA DE PIEDRA, e=20cm, ACABADO CARA VISTA | 3d | 2023-09-15 | 2023-09-17 | 2.4.2.2.5 | 59d | 74d |
|  | 5 | **REPOSICIÓN SIFON INOPERATIVO** |  | 2023-08-02 | 2023-09-13 |  |  |  |
| 2.5.1 |  | DEMOLICIÓN DE ESTRUCTURAS EXISTENTES | 3d | 2023-08-02 | 2023-08-04 | 1.5.3.5 | 12d | 0d |
| 2.5.2 |  | EXCAVACIÓN ESTRUCTURAL PARA OBRAS DE ARTE | 7d | 2023-08-05 | 2023-08-11 | 2.5.1 | 12d | 0d |
| 2.5.3 |  | COLOCACIÓN CAMA DE ARENA | 4d | 2023-08-12 | 2023-08-15 | 2.5.2 | 12d | 0d |
| 2.5.11 |  | CODOS HDPE DE 14" DN 355mm | 7d | 2023-08-16 | 2023-08-22 | 2.5.6 SS | 12d | 0d |
| 2.5.6 |  | TUBERÍAS DE 14" HDPE SDR21 DN 355mm | 7d | 2023-08-16 | 2023-08-22 | 2.5.3 | 12d | 0d |
| 2.5.5 |  | RELLENO COMÚN | 7d | 2023-08-23 | 2023-08-29 | 2.5.6, 2.5.11 | 12d | 0d |
| 2.5.4 |  | RELLENO ESTRUCTURAL PARA OBRAS DE ARTE CON MATERIAL PROPIO | 3d | 2023-08-30 | 2023-09-01 | 2.5.5 | 12d | 0d |
| 2.5.7 |  | CONCRETO f'c=100 kg/cm2 | 3d | 2023-09-02 | 2023-09-04 | 2.5.4 | 63d | 0d |
| 2.5.10 |  | ACERO DE REFUERZO fy=4200 kg/cm2 | 3d | 2023-09-05 | 2023-09-07 | 2.5.7 | 63d | 0d |
| 2.5.9 |  | ENCOFRADO Y DESENCOFRADO RECTO | 3d | 2023-09-08 | 2023-09-10 | 2.5.10 | 63d | 0d |
| 2.5.8 |  | CONCRETO f'c=280 kg/cm2 | 3d | 2023-09-11 | 2023-09-13 | 2.5.9 | 63d | 78d |

| ID | WBS | Activity | Duration | Start | Finish | Predecessors | Total float | Free float | Resources |
| --- | --- | --- | --- | --- | --- | --- | --- | --- | --- |
|  | 3 | **TRANSPORTE DE MATERIAL** |  | 2023-05-21 | 2023-11-05 |  |  |  |  |
| 3.5 |  | TRANSPORTE DE MATERIAL EXCEDENTE PARA DISTANCIAS <1KM | 130d | 2023-05-21 | 2023-09-27 | H3 | 4d | 0d | Operador Volquete [4742 h]; Volquete [4742 h] |
| 3.6 |  | TRANSPORTE DE MATERIAL EXCEDENTE PARA DISTANCIAS >1KM | 130d | 2023-05-21 | 2023-09-27 | 3.5 SS | 34d | 0d | Volquete [16442 h]; Operador Volquete [16442 h] |
| 3.3 |  | TRANSPORTE DE ROCA PARA DISTANCIAS <1KM | 110d | 2023-06-26 | 2023-10-13 | 1.5.3.7 SS | -12d | 0d | Operador Volquete [3037 h]; Volquete [3037 h] |
| 3.4 |  | TRANSPORTE DE ROCA PARA DISTANCIAS >1KM | 110d | 2023-06-26 | 2023-10-13 | 1.5.3.7 SS | -12d | 0d | Volquete [12197 h]; Operador Volquete [12197 h] |
| 3.1 |  | TRANSPORTE DE MATERIAL GRANULAR PARA DISTANCIAS <1KM | 90d | 2023-08-08 | 2023-11-05 | 2.1.2.3 SS | 10d | 25d | Operador Rodillo [378 h]; Volquete [378 h] |
| 3.2 |  | TRANSPORTE DE MATERIAL GRANULAR PARA DISTANCIAS >1KM | 90d | 2023-08-08 | 2023-11-05 | 2.1.2.3 SS | 10d | 25d | Volquete [76.08 h]; Operador Volquete [76.08 h] |
|  | 4 | **ARQUITECTURA Y PAISAJISMO** |  | 2023-09-02 | 2023-10-27 |  |  |  |  |
|  | 1 | **OBRAS PRELIMINARES** |  | 2023-09-02 | 2023-09-10 |  |  |  |  |
| 4.1.1 |  | MOVILIZACIÓN Y DEMOVILIZACIÓN DE EQUIPOS Y HERRAMIENTAS (ARQUITECTURA Y PAISAJISMO) | 4d | 2023-09-02 | 2023-09-05 | 2.5.4 | 12d | 0d |  |
| 4.1.2 |  | TRAZO Y REPLANTEO PRELIMINAR | 5d | 2023-09-06 | 2023-09-10 | 4.1.1 | 12d | 0d |  |
|  | 2 | **MOVIMIENTO DE TIERRAS** |  | 2023-09-11 | 2023-09-22 |  |  |  |  |
| 4.2.1 |  | EXCAVACIÓN MANUAL PARA INSTALACIÓN DE BORDILLOS Y CIMENTACIONES | 3d | 2023-09-11 | 2023-09-13 | 4.1.2 | 12d | 0d |  |
| 4.2.2 |  | EXCAVACIÓN PARA MEJORAMIENTO DE SUELO CON TIERRA VEGETAL | 6d | 2023-09-12 | 2023-09-17 | 4.2.1 SS+1d | 12d | 0d |  |
| 4.2.3 |  | ELIMINACION DE MATERIAL EXCEDENTE (DME´S) | 5d | 2023-09-18 | 2023-09-22 | 4.2.2 | 54d | 69d |  |
|  | 3 | **PAVIMENTOS, RECUBRIMIENTOS Y BORDILLOS** |  | 2023-09-18 | 2023-10-05 |  |  |  |  |
| 4.3.1 |  | PISO DE GRAVILLA | 3d | 2023-09-18 | 2023-09-20 | 4.2.2 | 12d | 0d |  |
| 4.3.2 |  | RECUBRIMIENTO DE PIEDRA DEL LUGAR e=0.05cm | 10d | 2023-09-21 | 2023-09-30 | 4.3.1 | 12d | 0d |  |
| 4.3.3 |  | BORDILLOS DE PIEDRA DEL LUGAR | 5d | 2023-10-01 | 2023-10-05 | 4.3.2 | 12d | 0d |  |
|  | 4 | **MOBILIARIOS, BARANDAS Y ESCALERAS** |  | 2023-10-06 | 2023-10-27 |  |  |  |  |
| 4.4.1 |  | ESCALERA DE CONCRETO SOBRE ENROCADO, CIMENTACION Y ANCLAJE | 4d | 2023-10-06 | 2023-10-09 | 4.3.3 | 12d | 0d |  |
| 4.4.2 |  | BARANDA DE MADERA EUCALIPTO CON SOGA, INCLUYE CIMENTACIÓN | 3d | 2023-10-10 | 2023-10-12 | 4.4.1 | 12d | 0d |  |
| 4.4.7 |  | BOLARDOS DE PIEDRA | 3d | 2023-10-13 | 2023-10-15 | 4.4.2 | 19d | 0d |  |
| 4.4.5 |  | POSTES DE ILUMINACIÓN, INCLUYE LUMINARIA Y CIMENTACIÓN | 3d | 2023-10-16 | 2023-10-18 | 4.4.7 | 19d | 0d |  |
| 4.4.4 |  | BANCAS DE CONCRETO, INCLUYE CIMENTACIÓN | 3d | 2023-10-19 | 2023-10-21 | 4.4.5 | 19d | 0d |  |
| 4.4.3 |  | TACHOS DE BASURA, INCLUYE CIMENTACIÓN | 3d | 2023-10-22 | 2023-10-24 | 4.4.4 | 19d | 0d |  |
| 4.4.6 |  | SEÑALETICA INFORMATIVA | 3d | 2023-10-25 | 2023-10-27 | 4.4.3 | 19d | 34d |  |

| ID | WBS | Activity | Duration | Start | Finish | Predecessors | Total float | Free float |
| --- | --- | --- | --- | --- | --- | --- | --- | --- |
|  | 5 | **INSTALACIÓN DE ALCORQUES** |  | 2023-10-06 | 2023-10-08 |  |  |  |
| 4.5.1 |  | ALCORQUES DE PIEDRA DE CANTO RODADO PARA ARBOLES | 3d | 2023-10-06 | 2023-10-08 | 4.3.3 | 38d | 53d |
|  | 5 | **PROGRAMA DE CIERRE DE OBRA** |  | 2023-05-24 | 2023-11-03 |  |  |  |
| 5.1 |  | ACONDICIONAMIENTO DE DEPOSITOS DE MATERIALES EXCEDENTES (DME) | 142d | 2023-05-24 | 2023-10-12 | 3.5 SS+3d, 3.6 SS+3d | 34d | 149d |
| 5.2 |  | RESTAURACIÓN DE ÁREAS DE INSTALACIONES PROVISIONALES | 15d | 2023-10-20 | 2023-11-03 | 5.1 SS, 4.4.2 FS+7d | 12d | 27d |
|  | 6 | **SEGURIDAD Y SALUD OCUPACIONAL** |  | 2023-05-16 | 2023-11-14 |  |  |  |
| 6.1 |  | SEGURIDAD Y SALUD OCUPACIONAL | 183d | 2023-05-16 | 2023-11-14 | H2 | 1d | 16d |
| 6.2 |  | IMPLEMENTACIÓN DEL PLAN PARA LA VIGILANCIA, PREVENCIÓN Y CONTROL DE COVID-19 EN EL TRABAJO | 183d | 2023-05-16 | 2023-11-14 | H2 | 1d | 16d |
